# Sample Staged ITSM Suite 1808 from 91 Upgrade Plan

Schedule from MS Project, 2018-08-31 to 2018-10-19.

## Calendars

- Standard: Mon-Fri 08:00-12:00, 13:00-17:00; Sat-Sun off.

## Resources

| Resource |
| --- |
| IT Ops |
| Remedy Admin |
| User Leads |
| DBA |
| Business Analyst |

## Schedule

| ID | WBS | Task | Type | Duration | Start | Finish | Predecessors | Total slack | Free slack | Constraint | Resources | Work |
| --- | --- | --- | --- | --- | --- | --- | --- | --- | --- | --- | --- | --- |
| 1 | 1 | **ITSM Suite 18.08 staged upgrade from ITSM Suite 9.1 version** |  | 35.33d | 2018-08-31 08:00 | 2018-10-19 10:38 |  |  |  |  |  | 408.8h |
| 2 | 1.1 | **Staged development upgrade** |  | 12.19d | 2018-08-31 08:00 | 2018-09-18 09:31 |  | 2.96d |  |  |  | 130.24h |
| 3 | 1.1.1 | Set up the development staging system |  | 3d | 2018-08-31 08:00 | 2018-09-04 17:00 |  | 1.02d | 0d |  | IT Ops | 24h |
| 4 | 1.1.2 | Capture a snapshot |  | 0.12d | 2018-09-05 08:00 | 2018-09-05 08:57 | 3 | 1.02d | 0d |  | Remedy Admin | 0.96h |
| 5 | 1.1.3 | **Upgrade the platform** |  | 0.26d | 2018-09-05 08:57 | 2018-09-05 11:02 | 4 | 2.96d | 0d |  |  | 2.56h |
| 6 | 1.1.3.1 | Upgrade the mid tier servers |  | 0.06d | 2018-09-05 08:57 | 2018-09-05 09:26 | 3 | 1.22d |  |  | IT Ops | 0.48h |
| 7 | 1.1.3.2 | Upgrade the AR System server |  | 0.13d | 2018-09-05 08:57 | 2018-09-05 10:00 |  | 1.02d | 0d |  | IT Ops | 1.04h |
| 8 | 1.1.3.3 | Upgrade Atrium Core (CMDB) |  | 0.13d | 2018-09-05 10:00 | 2018-09-05 11:02 | 7 | 1.02d |  |  | IT Ops | 1.04h |
| 9 | 1.1.4 | Adjust customizations |  | 2d | 2018-09-05 11:02 | 2018-09-07 11:02 | 5 | 2.96d | 0d |  | Remedy Admin | 16h |
| 10 | 1.1.5 | Upgrade secondary server platform |  | 0.06d | 2018-09-07 16:02 | 2018-09-07 16:31 | 11 | 2.96d | 0d |  | IT Ops | 0.48h |
| 11 | 1.1.6 | **Upgrade the applications to 18.05** |  | 0.5d | 2018-09-07 11:02 | 2018-09-07 16:02 | 9 |  |  |  |  | 4.24h |
| 12 | 1.1.6.1 | Upgrade IT Service Management (ITSM) to 18.05 |  | 0.25d | 2018-09-07 11:02 | 2018-09-07 14:02 |  | 2.96d | 0d |  | IT Ops | 2h |
| 13 | 1.1.6.2 | Upgrade Service Request Management (SRM) to 18.05 |  | 0.13d | 2018-09-07 14:02 | 2018-09-07 15:04 | 12 | 2.96d | 0d |  | IT Ops | 1.04h |
| 14 | 1.1.6.3 | Uprade Service Level Management (SLM) to 18.05 |  | 0.12d | 2018-09-07 15:04 | 2018-09-07 16:02 | 13 | 2.96d |  |  | IT Ops | 0.96h |
| 15 | 1.1.6.4 | Upgrade the applications to 18.08 using deployment packages |  | 0.03d | 2018-09-07 11:02 | 2018-09-07 11:16 |  | 3.43d |  |  |  |  |
| 16 | 1.1.6.5 | Upgrade IT Service Management (ITSM) to 18.08 using ITSM deployment package |  | 0.03d | 2018-09-07 11:02 | 2018-09-07 11:16 |  | 3.43d |  |  | IT Ops | 0.24h |
| 17 | 1.1.6.6 | Upgrade Service Request Management (SRM) to 18.08 using SRM deployment package | milestone | 0d | 2018-09-07 11:02 | 2018-09-07 11:02 |  | 3.46d |  |  | IT Ops |  |
| 18 | 1.1.6.7 | Uprade Service Level Management (SLM) to 18.08 using SLM deployment package | milestone | 0d | 2018-09-07 11:02 | 2018-09-07 11:02 |  | 3.46d |  |  | IT Ops |  |
| 19 | 1.1.7 | Reconcile customizations |  | 2d | 2018-09-07 16:31 | 2018-09-11 16:31 | 10 | 2.96d | 0d |  | Remedy Admin | 16h |
| 20 | 1.1.8 | Update the integrations |  | 1d | 2018-09-11 16:31 | 2018-09-12 16:31 | 19 | 2.96d | 0d |  | IT Ops; Remedy Admin | 16h |
| 21 | 1.1.9 | Perform upgrade testing |  | 3d | 2018-09-12 16:31 | 2018-09-17 16:31 | 20 | 2.96d | 0d |  | Remedy Admin; User Leads | 48h |
| 22 | 1.1.10 | Migrate customizations |  | 0.25d | 2018-09-17 16:31 | 2018-09-18 09:31 | 21 | 2.96d |  |  | Remedy Admin | 2h |
| 23 | 1.2 | **Staged QA upgrade** |  | 11.34d | 2018-09-21 09:12 | 2018-10-08 11:55 | 2 | 0d |  |  |  | 173.28h |
| 24 | 1.2.1 | Set up the QA staging system |  | 3d | 2018-09-21 09:12 | 2018-09-26 09:12 |  | 0d |  | as late as possible | IT Ops | 24h |

| ID | WBS | Task | Type | Duration | Start | Finish | Predecessors | Total slack | Free slack | Resources | Work |
| --- | --- | --- | --- | --- | --- | --- | --- | --- | --- | --- | --- |
| 25 | 1.2.2 | **Upgrade the platform** |  | 0.5d | 2018-09-26 09:12 | 2018-09-26 14:12 | 24 | 0d |  |  | 7.28h |
| 26 | 1.2.2.1 | Upgrade the mid tier servers |  | 0.06d | 2018-09-26 09:12 | 2018-09-26 09:40 | 24 | 8.28d |  | IT Ops | 0.48h |
| 27 | 1.2.2.2 | Upgrade the AR System server |  | 0.13d | 2018-09-26 09:12 | 2018-09-26 10:14 | 24 | 8.08d | 0d | IT Ops | 1.04h |
| 28 | 1.2.2.3 | Upgrade Atrium Core (CMDB) |  | 0.13d | 2018-09-26 10:14 | 2018-09-26 11:16 | 27 | 8.08d |  | IT Ops | 1.04h |
| 29 | 1.2.2.4 | Upgrade secondary server platform |  | 0.06d | 2018-09-26 09:12 | 2018-09-26 09:40 |  | 0d |  | IT Ops | 0.48h |
| 30 | 1.2.2.5 | **Upgrade the applications to 18.05** |  | 0.5d | 2018-09-26 09:12 | 2018-09-26 14:12 |  | 0.06d |  |  | 4.24h |
| 31 | 1.2.2.5.1 | Upgrade IT Service Management (ITSM) to 18.05 |  | 0.25d | 2018-09-26 09:12 | 2018-09-26 11:12 |  | 7.84d | 0d | IT Ops | 2h |
| 32 | 1.2.2.5.2 | Upgrade Service Request Management (SRM) to 18.05 |  | 0.13d | 2018-09-26 11:12 | 2018-09-26 13:14 | 31 | 7.84d | 0d | IT Ops | 1.04h |
| 33 | 1.2.2.5.3 | Uprade Service Level Management (SLM) to 18.05 |  | 0.12d | 2018-09-26 13:14 | 2018-09-26 14:12 | 32 | 7.84d |  | IT Ops | 0.96h |
| 34 | 1.2.2.5.4 | Upgrade the applications to 18.08 using deployment packages |  | 0.03d | 2018-09-26 09:12 | 2018-09-26 09:26 |  | 8.31d |  |  |  |
| 35 | 1.2.2.5.5 | Upgrade IT Service Management (ITSM) to 18.08 using ITSM deployment package |  | 0.03d | 2018-09-26 09:40 | 2018-09-26 09:55 | 29 | 0d |  | IT Ops | 0.24h |
| 36 | 1.2.2.5.6 | Upgrade Service Request Management (SRM) to 18.08 using SRM deployment package | milestone | 0d | 2018-09-26 09:55 | 2018-09-26 09:55 | 35 | 0d |  | IT Ops |  |
| 37 | 1.2.2.5.7 | Uprade Service Level Management (SLM) to 18.08 using SLM deployment package | milestone | 0d | 2018-09-26 09:55 | 2018-09-26 09:55 | 36 | 0d |  | IT Ops |  |
| 38 | 1.2.3 | Update the integrations |  | 1d | 2018-09-26 09:55 | 2018-09-27 09:55 | 37 | 0d |  | IT Ops; Remedy Admin | 16h |
| 39 | 1.2.4 | Perform upgrade testing |  | 1.5d | 2018-09-27 09:55 | 2018-09-28 14:55 | 38 | 0d |  | Remedy Admin; User Leads | 24h |
| 40 | 1.2.5 | Resolve issues uncovered during testing |  | 1d | 2018-09-28 14:55 | 2018-10-01 14:55 | 39 | 0d |  | Remedy Admin | 8h |
| 41 | 1.2.6 | Back up the database |  | 0.25d | 2018-10-01 14:55 | 2018-10-01 16:55 | 40 | 0d |  | DBA | 2h |
| 42 | 1.2.7 | Conduct user training (new features, changed functionality) |  | 1d | 2018-10-01 16:55 | 2018-10-02 16:55 | 41 | 0d |  | Remedy Admin; User Leads; Business Analyst | 24h |
| 43 | 1.2.8 | Conduct User Acceptance Testing (UAT) |  | 3d | 2018-10-02 16:55 | 2018-10-05 16:55 | 42 | 0d |  | Business Analyst; User Leads | 48h |
| 44 | 1.2.9 | Conduct performance load testing (end-to-end) |  | 0.5d | 2018-10-05 16:55 | 2018-10-08 11:55 | 43 | 0d |  | Business Analyst; DBA; IT Ops; Remedy Admin; User Leads | 20h |
| 45 | 1.3 | **Staged production upgrade** |  | 8.84d | 2018-10-08 11:55 | 2018-10-19 10:38 | 23 | 0d |  |  | 105.28h |
| 46 | 1.3.1 | Set up the production staging system |  | 3d | 2018-10-08 11:55 | 2018-10-11 11:55 |  | 0d |  | IT Ops | 24h |
| 47 | 1.3.2 | Apply restrictions to current production |  | 0.25d | 2018-10-11 11:55 | 2018-10-11 14:55 | 46 | 0d |  | Remedy Admin | 2h |
| 48 | 1.3.3 | **Upgrade the platform** |  | 0.26d | 2018-10-11 14:55 | 2018-10-11 17:00 | 47 | 0d |  |  | 7.28h |
| 49 | 1.3.3.1 | Upgrade the mid tier servers |  | 0.06d | 2018-10-11 14:55 | 2018-10-11 15:24 | 46 | 5.53d |  | IT Ops | 0.48h |
| 50 | 1.3.3.2 | Upgrade the AR System server |  | 0.13d | 2018-10-11 14:55 | 2018-10-11 15:57 |  | 5.33d | 0d | IT Ops | 1.04h |
| 51 | 1.3.3.3 | Upgrade Atrium Core (CMDB) |  | 0.13d | 2018-10-11 15:57 | 2018-10-11 17:00 | 50 | 5.33d |  | IT Ops | 1.04h |
| 52 | 1.3.3.4 | Upgrade secondary server platform |  | 0.06d | 2018-10-11 15:09 | 2018-10-11 15:38 | 57, 34, 15 | 0d |  | IT Ops | 0.48h |

| ID | WBS | Task | Type | Duration | Start | Finish | Predecessors | Total slack | Resources | Work |
| --- | --- | --- | --- | --- | --- | --- | --- | --- | --- | --- |
| 53 | 1.3.3.5 | **Upgrade the applications to 18.05** |  | 0.25d | 2018-10-11 14:55 | 2018-10-11 16:55 |  | 5.34d |  | 4h |
| 54 | 1.3.3.5.1 | Upgrade IT Service Management (ITSM) to 18.05 |  | 0.25d | 2018-10-11 14:55 | 2018-10-11 16:55 |  | 5.34d | IT Ops | 2h |
| 55 | 1.3.3.5.2 | Upgrade Service Request Management (SRM) to 18.05 |  | 0.13d | 2018-10-11 14:55 | 2018-10-11 15:57 |  | 5.46d | IT Ops | 1.04h |
| 56 | 1.3.3.5.3 | Uprade Service Level Management (SLM) to 18.05 |  | 0.12d | 2018-10-11 14:55 | 2018-10-11 15:52 |  | 5.47d | IT Ops | 0.96h |
| 57 | 1.3.3.6 | **Upgrade the applications to 18.08 using deployment packages** |  | 0.03d | 2018-10-11 14:55 | 2018-10-11 15:09 |  | 0d |  | 0.24h |
| 58 | 1.3.3.6.1 | Upgrade IT Service Management (ITSM) to 18.08 using ITSM deployment package |  | 0.03d | 2018-10-11 14:55 | 2018-10-11 15:09 |  | 0d | IT Ops | 0.24h |
| 59 | 1.3.3.6.2 | Upgrade Service Request Management (SRM) to 18.08 using SRM deployment package | milestone | 0d | 2018-10-11 15:09 | 2018-10-11 15:09 | 58 | 0d | IT Ops |  |
| 60 | 1.3.3.6.3 | Uprade Service Level Management (SLM) to 18.08 using SLM deployment package | milestone | 0d | 2018-10-11 15:09 | 2018-10-11 15:09 | 59 | 0d | IT Ops |  |
| 61 | 1.3.4 | Import the reconciled customizations |  | 0.25d | 2018-10-11 15:38 | 2018-10-12 08:38 | 52 | 0d | Remedy Admin | 2h |
| 62 | 1.3.5 | Update the integrations |  | 1d | 2018-10-12 08:38 | 2018-10-15 08:38 | 61 | 0d | IT Ops; Remedy Admin | 16h |
| 63 | 1.3.6 | Apply non-data fixes |  | 0.25d | 2018-10-15 08:38 | 2018-10-15 10:38 | 62 | 0d | Remedy Admin | 2h |
| 64 | 1.3.7 | Back up the production staging database |  | 0.25d | 2018-10-15 10:38 | 2018-10-15 13:38 | 63 | 0d | DBA | 2h |
| 65 | 1.3.8 | Perform upgrade testing |  | 1.5d | 2018-10-15 13:38 | 2018-10-17 08:38 | 64 | 0d | Remedy Admin; User Leads | 24h |
| 66 | 1.3.9 | Restore the production staging database |  | 0.25d | 2018-10-17 08:38 | 2018-10-17 10:38 | 65 | 0d | DBA | 2h |
| 67 | 1.3.10 | Perform Delta Data Migration (DDM) |  | 1d | 2018-10-17 10:38 | 2018-10-18 10:38 | 66 | 0d | Remedy Admin | 8h |
| 68 | 1.3.11 | Back up the production staging database |  | 0.25d | 2018-10-18 10:38 | 2018-10-18 13:38 | 67 | 0d | DBA | 2h |
| 69 | 1.3.12 | Re-index Full Text Search (FTS) |  | 0.25d | 2018-10-18 13:38 | 2018-10-18 15:38 | 68 | 0d | Remedy Admin | 2h |
| 70 | 1.3.13 | Perform cutover and final Delta Data Migration (DDM) |  | 0.25d | 2018-10-18 15:38 | 2018-10-19 08:38 | 69 | 0d | IT Ops; Remedy Admin | 4h |
| 71 | 1.3.14 | Perform go-live activities |  | 0.25d | 2018-10-19 08:38 | 2018-10-19 10:38 | 70 | 0d | Business Analyst; DBA; IT Ops; Remedy Admin | 8h |
